# TPC Schedule in SXL2

Schedule from MS Project, 2006-10-30 to 2006-12-14.
ALICE

## Calendars

- Standard: Mon-Fri 08:00-12:00, 13:00-17:00; Sat-Sun off. Exceptions (off unless hours are given): 2006-11-04 to 2006-11-05 08:00-12:00, 13:00-17:00, 2006-11-11 to 2006-11-12 08:00-12:00, 13:00-17:00, 2006-11-18 to 2006-11-19 08:00-12:00, 13:00-17:00, 2006-11-25 to 2006-11-26 08:00-12:00, 13:00-17:00.

## Resources

| Resource |
| --- |
| TA2 |
| D.P |
| TA2 / ITS |
| ITS |
| ITS / CERN |
| Turin |
| Padova |
| NBI |
| CERN Va |
| Heidelberg |
| Bologna |
| Jens |
| Borge |
| Rudi |
| Joachim |
| Chilo |
| GWG |
| Luciano |
| Danilo |
| PG |
| Wolf |
| JC |
| TS1 |
| TS2 |
| TS1,TS2 |
| Toni |
| Joachim, Marco |
| Uli, Danilo |
| Joachim, Toni |
| Rudi, Danilo |
| Joachim, JC + |
| Luciono |
| Rainer, Rudi |
| Rainer |
| Chilo + |
| techn |
| Joachim + DF |
| Joachim + Toni |
| Rainer + Joachim + CW |
| Uli |
| Rainer + |
| etchn |
| 97 |
| Uli + |
| LM |
| JB, Marco |
| JB, Toni |
| JB + DF |
| JB, JC + |
| Rainer + JB + CW |
| DV |
| Uli, DV |
| Rudi, DV |
| RS, DV |
| Rainer, RS |
| RR |
| RR + JB + CW |
| RR + |
| RR, RS |
| CG + |
| CG |
| RR,JB,CW |
| CG+ |
| RR+ |
| Uli+ |
| RR,RS |
| JB,DF |
| RS,DV |
| JB,JC+ |
| JC+ |
| RS |
| CG,PG |
| Danilo, Uli |
| Chilo, Rudi |
| JC + tc |
| Uli, JC |
| Uli, Rudi |
| Antoine |
| Simonetti |
| Antje |
| Thomas |
| ??+ tc |
| ?? + tc |
| Bergen? |
| Daniel |
| Peter |
| Daniel, Thomas |
| Luciano, Joachim ++ |

## Schedule

| ID | Task | Duration | Start | Finish | Predecessors | Total slack | Free slack | Constraint | Resources | Work |
| --- | --- | --- | --- | --- | --- | --- | --- | --- | --- | --- |
| 1 | completion of heat screen in SF | 15d | 2006-11-16 | 2006-11-30 |  | 13d |  | start no earlier than 2006-11-16 | Daniel, Thomas | 120h |
| 2 | C-side commissioning phase 2 | 21d | 2006-10-30 | 2006-11-19 |  | 2d | 0d | start no earlier than 2006-10-30 | Luciano, Joachim ++ | 168h |
| 3 | remove VHV cable | 1d | 2006-11-20 | 2006-11-20 | 2 | 20d | 0d | start no earlier than 2006-11-07 | Joachim | 8h |
| 4 | disconnect services C-side, finalize covers | 2d | 2006-11-21 | 2006-11-22 | 3 | 20d | 8d | start no earlier than 2006-11-07 | Bergen? | 16h |
| 5 | water manifold inner heat screen C-side | 2d | 2006-11-27 | 2006-11-28 | 26 | 0d |  | start no earlier than 2006-11-27 | ?? + tc | 16h |
| 6 | leak test manifold C-side | 1d | 2006-11-29 | 2006-11-29 | 5 | 0d |  | start no earlier than 2006-11-08 | Thomas | 8h |
| 7 | water manifold inner heat screen A-side | 2d | 2006-11-30 | 2006-12-01 | 6 | 0d |  | start no earlier than 2006-11-07 | ??+ tc | 16h |
| 8 | leak test water manifold A-side | 1d | 2006-12-04 | 2006-12-04 | 7 | 0d |  | start no earlier than 2006-11-08 | Thomas | 8h |
| 9 | unhook gas | 1d | 2006-11-20 | 2006-11-20 | 2 | 2d | 0d | start no earlier than 2006-11-07 | Chilo | 8h |
| 10 | fix CO2 bottle to DF | 1d | 2006-11-21 | 2006-11-21 | 9 | 19d |  | start no earlier than 2006-11-07 | Chilo | 8h |
| 11 | purge TPC with air | 3d | 2006-11-21 | 2006-11-23 | 9 | 2d | 0d | start no earlier than 2006-11-07 | Chilo | 24h |
| 12 | MT ready | 1d | 2006-10-31 | 2006-10-31 |  | 37d | 0d | start no earlier than 2006-10-31 |  |  |
| 13 | remove A00 FEE | 1d | 2006-11-01 | 2006-11-01 | 12 | 37d | 0d | start no earlier than 2006-11-01 | Antoine | 8h |
| 14 | remove FEE frame | 1d | 2006-11-02 | 2006-11-02 | 13 | 37d | 5d | start no earlier than 2006-11-02 | Uli, Rudi | 8h |
| 15 | remove A00 pt1000 | 1d | 2006-11-08 | 2006-11-08 | 14 | 32d |  | start no earlier than 2006-11-08 | Rudi | 8h |
| 16 | spare OROC testing | 13d | 2006-11-09 | 2006-11-21 |  | 4d | 2d | start no earlier than 2006-11-09 | Chilo, Rudi | 104h |
| 17 | prepare small pieces | 10d | 2006-11-01 | 2006-11-10 |  | 30d |  | start no earlier than 2006-11-01 | Danilo, Uli | 80h |
| 18 | clear out clean room | 2d | 2006-11-06 | 2006-11-07 |  | 30d | 0d | start no earlier than 2006-11-06 |  |  |
| 19 | cleaning | 3d | 2006-11-08 | 2006-11-10 | 18 | 30d |  |  |  |  |
| 20 | prepare platform | 4d | 2006-11-13 | 2006-11-16 |  | 24d |  | start no earlier than 2006-11-13 | JC | 32h |
| 21 | remove scaffold A-side | 1d | 2006-11-13 | 2006-11-13 |  | 25d | 0d | start no earlier than 2006-11-13 | JC | 8h |
| 22 | remove laser | 1d | 2006-11-14 | 2006-11-14 | 21 | 25d | 0d |  | Borge | 8h |
| 23 | remove VHV | 1d | 2006-11-15 | 2006-11-15 | 22 | 25d |  |  | Joachim | 8h |
| 24 | move platform into clean room | 1d | 2006-11-20 | 2006-11-20 |  | 2d | 0d | start no earlier than 2006-11-20 | JC | 8h |
| 25 | complete platform | 3d | 2006-11-21 | 2006-11-23 | 24 | 2d | 0d |  | JC + tc | 24h |
| 26 | exchange OROC | 1d | 2006-11-24 | 2006-11-24 | 25, 11, 16 | 2d | 0d |  | Uli, JC | 8h |
| 27 | leak test | 1d | 2006-11-25 | 2006-11-25 | 26 | 6d | 0d | start no earlier than 2006-11-08 | Joachim | 8h |
| 28 | contingency | 1d | 2006-11-26 | 2006-11-26 | 27 | 6d | 0d |  |  |  |
| 29 | mount pt1000 | 1d? | 2006-11-27 | 2006-11-27 | 28 | 6d | 0d | start no earlier than 2006-11-08 |  |  |
| 30 | install IST rail section | 1d | 2006-11-27 | 2006-11-27 | 28 | 13d |  | start no earlier than 2006-11-07 | Simonetti | 8h |
| 31 | mount frames services | 2d | 2006-11-28 | 2006-11-29 | 29 | 6d | 0d |  | Uli, Rudi | 16h |
| 32 | mount FEE | 1d | 2006-11-30 | 2006-11-30 | 31 | 6d | 0d |  | Antoine | 8h |
| 33 | test FEE, finalize covers A-side | 2d | 2006-12-01 | 2006-12-04 | 32 | 6d | 0d |  | Luciano | 16h |
| 34 | open roof, remove ACORDE | 2d | 2006-12-05 | 2006-12-06 | 33 | 6d |  | start no earlier than 2006-11-07 | Joachim | 16h |
| 35 | remove scaffolds C | 1d | 2006-12-05 | 2006-12-05 | 33, 4 | 7d |  | start no earlier than 2006-11-27 | JC | 8h |
| 36 | dismount and remove yellow platform | 1d | 2006-12-05 | 2006-12-05 | 8 | 0d |  | start no earlier than 2006-11-07 | JC + tc | 8h |
| 37 | survey A/C | 1d | 2006-12-06 | 2006-12-06 | 36 | 0d |  | start no earlier than 2006-11-07 | Antje | 8h |
| 38 | remove wall | 2d | 2006-12-07 | 2006-12-08 | 37 | 0d |  | start no earlier than 2006-11-07 | JC | 16h |
| 39 | package TPC | 1d | 2006-12-11 | 2006-12-11 | 38 | 0d |  | start no earlier than 2006-11-08 |  |  |
| 40 | TPC with crane to hydraulic station | 1d | 2006-12-12 | 2006-12-12 | 39 | 0d |  | start no earlier than 2006-11-07 |  |  |
| 41 | TPC with trailer to SX2 | 1d | 2006-12-13 | 2006-12-13 | 40 | 0d |  | start no earlier than 2006-11-07 |  |  |
| 42 | TPC with cranes from SX2 to UX2 | 1d | 2006-12-14 | 2006-12-14 | 41 | 0d |  | start no earlier than 2006-11-07 |  |  |
| 43 | prepare support beams for transport | 1d | 2006-11-07 | 2006-11-07 |  | 33d |  | start no earlier than 2006-11-07 | JC | 8h |
| 44 | black paint inner heat screen | 1d | 2006-11-07 | 2006-11-07 |  | 33d |  | start no earlier than 2006-11-07 | JC | 8h |
| 45 | tension bretelles | 1d | 2006-11-07 | 2006-11-07 |  | 33d |  | start no earlier than 2006-11-07 | Daniel | 8h |
| 46 | fix track-rods | 1d | 2006-11-07 | 2006-11-07 |  | 33d |  | start no earlier than 2006-11-07 | Peter | 8h |
