# TPC Schedule in SXL2

Schedule from MS Project, 2006-10-30 to 2007-02-02.
ALICE

## Calendars

- Standard: Mon-Sat 08:00-12:00, 13:00-17:00; Sun off. Exceptions (off unless hours are given): 2006-11-04 to 2006-11-05 08:00-12:00, 13:00-17:00, 2006-11-11 to 2006-11-12 08:00-12:00, 13:00-17:00, 2006-11-18 to 2006-11-19 08:00-12:00, 13:00-17:00, 2006-11-25 to 2006-11-26 08:00-12:00, 13:00-17:00, 2006-12-22 to 2007-01-07.

## Resources

| Resource |
| --- |
| TA2 |
| D.P |
| TA2 / ITS |
| ITS |
| ITS / CERN |
| Turin |
| Padova |
| NBI |
| CERN Va |
| Heidelberg |
| Bologna |
| Jens |
| Borge |
| Rudi |
| Joachim |
| Chilo |
| GWG |
| Luciano |
| Danilo |
| PG |
| Wolf |
| JC |
| TS1 |
| TS2 |
| TS1,TS2 |
| Toni |
| Joachim, Marco |
| Uli, Danilo |
| Joachim, Toni |
| Rudi, Danilo |
| Joachim, JC + |
| Luciono |
| Rainer, Rudi |
| Rainer |
| Chilo + |
| techn |
| Joachim + DF |
| Joachim + Toni |
| Rainer + Joachim + CW |
| Uli |
| Rainer + |
| etchn |
| 97 |
| Uli + |
| LM |
| JB, Marco |
| JB, Toni |
| JB + DF |
| JB, JC + |
| Rainer + JB + CW |
| DV |
| Uli, DV |
| Rudi, DV |
| RS, DV |
| Rainer, RS |
| RR |
| RR + JB + CW |
| RR + |
| RR, RS |
| CG + |
| CG |
| RR,JB,CW |
| CG+ |
| RR+ |
| Uli+ |
| RR,RS |
| JB,DF |
| RS,DV |
| JB,JC+ |
| JC+ |
| RS |
| CG,PG |
| Danilo, Uli |
| Chilo, Rudi |
| JC + tc |
| Uli, JC |
| Uli, Rudi |
| Antoine |
| Simonetti |
| Antje |
| Thomas |
| ??+ tc |
| ?? + tc |
| Bergen? |
| Daniel |
| Peter |
| Daniel, Thomas |
| Luciano, Joachim ++ |
| ThomasJoachim |

## Schedule

| ID | WBS | Task | Duration | Start | Finish | Predecessors | Total slack | Free slack | Constraint | Resources | Work |
| --- | --- | --- | --- | --- | --- | --- | --- | --- | --- | --- | --- |
| 1 | 1 | completion of heat screen in SF | 15d | 2006-11-16 | 2006-11-30 |  | 40d |  | start no earlier than 2006-11-16 | Daniel, Thomas | 120h |
| 2 | 2 | C-side commissioning phase 2 | 21d | 2006-10-30 | 2006-11-19 |  | 5d | 0d | start no earlier than 2006-10-30 | Luciano, Joachim ++ | 168h |
| 3 | 3 | contingency | 4d | 2006-11-20 | 2006-11-23 | 2 | 4d | 0d | start no earlier than 2006-11-12 |  |  |
| 4 | 4 | remove VHV cable | 1d | 2006-11-24 | 2006-11-24 | 3 | 13d | 0d | start no earlier than 2006-11-07 | Joachim | 8h |
| 5 | 5 | disconnect services C-side, finalize covers | 2d | 2006-11-25 | 2006-11-26 | 4 | 13d | 0d | start no earlier than 2006-11-07 | Bergen? | 16h |
| 6 | 6 | water manifold inner heat screen C-side | 2d | 2006-11-27 | 2006-11-28 | 5 | 13d | 0d | start no earlier than 2006-11-27 | ?? + tc | 16h |
| 7 | 7 | leak test manifold C-side | 1d | 2006-11-29 | 2006-11-29 | 6 | 13d | 8d | start no earlier than 2006-11-08 | Thomas | 8h |
| 8 | 8 | water manifold inner heat screen A-side | 2d | 2006-12-09 | 2006-12-11 | 7, 34 | 5d | 0d | start no earlier than 2006-11-07 | ?? + tc | 16h |
| 9 | 9 | leak test water manifold A-side | 1d | 2006-12-12 | 2006-12-12 | 8 | 5d | 0d | start no earlier than 2006-11-08 | Thomas | 8h |
| 10 | 10 | unhook gas | 1d | 2006-11-24 | 2006-11-24 | 3 | 5d | 0d | start no earlier than 2006-11-07 | Chilo | 8h |
| 11 | 11 | fix CO2 bottle to DF | 1d | 2006-11-25 | 2006-11-25 | 10 | 45d |  | start no earlier than 2006-11-07 | Chilo | 8h |
| 12 | 12 | purge TPC with air | 3d | 2006-11-25 | 2006-11-27 | 10 | 5d | 0d | start no earlier than 2006-11-07 | Chilo | 24h |
| 13 | 13 | MT ready | 1d | 2006-10-31 | 2006-10-31 |  | 67d | 0d | start no earlier than 2006-10-31 | JC | 8h |
| 14 | 14 | remove A00 FEE | 1d | 2006-11-01 | 2006-11-01 | 13 | 67d | 0d | start no earlier than 2006-11-01 | Antoine | 8h |
| 15 | 15 | remove FEE frame | 1d | 2006-11-02 | 2006-11-02 | 14 | 67d | 5d | start no earlier than 2006-11-02 | Uli; Rudi | 16h |
| 16 | 16 | remove A00 pt1000 | 1d | 2006-11-08 | 2006-11-08 | 15 | 62d |  | start no earlier than 2006-11-08 | Rudi | 8h |
| 17 | 17 | spare OROC testing | 13d | 2006-11-09 | 2006-11-21 |  | 11d | 6d | start no earlier than 2006-11-09 | Chilo; Rudi | 208h |
| 18 | 18 | prepare small pieces | 5d | 2006-11-01 | 2006-11-05 |  | 65d |  | start no earlier than 2006-11-01 | Danilo; Uli | 80h |
| 19 | 19 | clear out clean room | 2d | 2006-11-06 | 2006-11-07 |  | 58d | 0d | start no earlier than 2006-11-06 |  |  |
| 20 | 20 | cleaning | 3d | 2006-11-08 | 2006-11-10 | 19 | 58d |  |  |  |  |
| 21 | 21 | prepare platform | 4d | 2006-11-13 | 2006-11-16 |  | 54d |  | start no earlier than 2006-11-13 | JC | 32h |
| 22 | 22 | remove scaffold A-side | 1d | 2006-11-13 | 2006-11-13 |  | 55d | 0d | start no earlier than 2006-11-13 | JC | 8h |
| 23 | 23 | remove laser | 1d | 2006-11-14 | 2006-11-14 | 22 | 55d | 0d |  | Borge | 8h |
| 24 | 24 | remove VHV | 1d | 2006-11-15 | 2006-11-15 | 23 | 55d |  |  | Joachim | 8h |
| 25 | 25 | move platform into clean room | 1d | 2006-11-20 | 2006-11-20 |  | 9d | 0d | start no earlier than 2006-11-20 | JC | 8h |
| 26 | 26 | complete platform | 3d | 2006-11-21 | 2006-11-23 | 25 | 9d | 4d |  | JC + tc | 24h |
| 27 | 27 | exchange OROC A00 | 1d | 2006-11-28 | 2006-11-28 | 26, 12, 17 | 5d | 0d |  | Uli; JC | 16h |
| 28 | 28 | leak test | 1d | 2006-11-29 | 2006-11-29 | 27 | 5d | 0d | start no earlier than 2006-11-08 | Joachim | 8h |
| 29 | 29 | contingency | 2d | 2006-11-30 | 2006-12-01 | 28 | 4d | 0d |  |  |  |
| 30 | 30 | mount pt1000 | 1d | 2006-12-02 | 2006-12-02 | 29 | 5d | 0d | start no earlier than 2006-11-08 | Rudi; Uli | 16h |
| 31 | 31 | install IST rail section | 1d | 2006-12-02 | 2006-12-02 | 29 | 38d |  | start no earlier than 2006-11-07 | Simonetti | 8h |
| 32 | 32 | mount frames services | 2d | 2006-12-04 | 2006-12-05 | 30 | 5d | 0d |  | Uli; Rudi | 32h |
| 33 | 33 | mount FEE | 1d | 2006-12-06 | 2006-12-06 | 32 | 5d | 0d |  | Antoine | 8h |
| 34 | 34 | test FEE, finalize covers A-side | 2d | 2006-12-07 | 2006-12-08 | 33 | 5d | 0d |  | Luciano | 16h |
| 35 | 35 | open roof, remove ACORDE | 2d | 2006-12-09 | 2006-12-11 | 34 | 31d |  | start no earlier than 2006-11-07 | Joachim | 16h |
| 36 | 36 | remove scaffolds C | 1d | 2006-12-09 | 2006-12-09 | 34, 7 | 32d |  | start no earlier than 2006-11-27 | JC | 8h |
| 37 | 37 | dismount and remove yellow platform | 2d | 2006-12-13 | 2006-12-14 | 9, 34 | 5d | 0d | start no earlier than 2006-11-07 | JC + tc | 16h |
| 38 | 38 | survey A/C | 1d | 2006-12-15 | 2006-12-15 | 37 | 5d |  | start no earlier than 2006-11-07 | Antje | 8h |
| 39 | 39 | package TPC | 1d | 2006-12-16 | 2006-12-16 | 38 | 4d |  | start no earlier than 2006-11-08 | Thomas; Joachim | 16h |
| 40 | 40 | remove wall | 2d | 2007-01-08 | 2007-01-09 | 39 | 0d |  | start no earlier than 2007-01-08 | JC | 16h |
| 41 | 41 | TPC with crane to hydraulic station | 1d | 2007-01-10 | 2007-01-10 | 40 | 0d |  | start no earlier than 2006-11-07 |  |  |
| 42 | 42 | TPC with trailer to SX2 | 1d | 2007-01-11 | 2007-01-11 | 41 | 0d |  | start no earlier than 2006-11-07 |  |  |
| 43 | 43 | TPC with cranes from SX2 to UX2 | 1d | 2007-01-12 | 2007-01-12 | 42 | 0d |  | start no earlier than 2006-11-07 |  |  |
| 44 | 44 | prepare support beams for transport | 4d | 2006-11-13 | 2006-11-16 |  | 52d |  | start no earlier than 2006-11-13 | JC | 32h |
| 45 | 45 | black paint inner heat screen | 2d | 2006-11-20 | 2006-11-21 |  | 47d |  | start no earlier than 2006-11-20 | JC | 16h |
| 46 | 46 | tension bretelles | 1d | 2006-11-15 | 2006-11-15 |  | 53d |  | start no earlier than 2006-11-15 | Daniel | 8h |
| 47 | 47 | fix track-rods | 1d | 2006-11-15 | 2006-11-15 |  | 53d |  | start no earlier than 2006-11-15 | Peter | 8h |

| ID | WBS | Task | Duration | Start | Finish | Predecessors | Total slack | Free slack | Constraint |
| --- | --- | --- | --- | --- | --- | --- | --- | --- | --- |
| 48 | 48 | **TPC installation phase 3a** | 12d | 2007-01-13 | 2007-01-26 | 43 | 0d |  |  |
| 49 | 48.1 | align DF to SF | 3d | 2007-01-13 | 2007-01-16 |  | 0d |  | start no earlier than 2006-11-13 |
| 50 | 48.2 | install transfer rails | 1d | 2007-01-17 | 2007-01-17 | 49 | 0d |  | start no earlier than 2006-11-13 |
| 51 | 48.3 | move to IP under survey | 3d | 2007-01-18 | 2007-01-20 | 50 | 0d |  | start no earlier than 2006-11-13 |
| 52 | 48.4 | align TPC at IP | 2d | 2007-01-22 | 2007-01-23 | 51 | 8d | 0d | start no earlier than 2006-11-13 |
| 53 | 48.5 | align IST rails at absorber | 1d | 2007-01-24 | 2007-01-24 | 52 | 8d |  | start no earlier than 2006-11-13 |
| 54 | 48.6 | install DF platform | 3d | 2007-01-22 | 2007-01-24 | 51 | 0d |  | start no earlier than 2006-11-13 |
| 55 | 48.7 | move TPC to parking | 2d | 2007-01-25 | 2007-01-26 | 54 | 0d |  | start no earlier than 2006-11-13 |
| 56 | 49 | Install SF platform | 1d | 2007-01-27 | 2007-01-27 | 55 | 5d |  | start no earlier than 2006-11-13 |
| 57 | 50 | Install IST table + rails | 6d | 2007-01-27 | 2007-02-02 | 55 | 0d |  | start no earlier than 2006-11-13 |
