# TPC Schedule in SXL2

Schedule from MS Project, 2006-10-30 to 2007-02-02.
ALICE

## Calendars

- Standard: Mon-Sat 08:00-12:00, 13:00-17:00; Sun off. Exceptions (off unless hours are given): 2006-11-04 to 2006-11-05 08:00-12:00, 13:00-17:00, 2006-11-11 to 2006-11-12 08:00-12:00, 13:00-17:00, 2006-11-18 to 2006-11-19 08:00-12:00, 13:00-17:00, 2006-11-25 to 2006-11-26 08:00-12:00, 13:00-17:00, 2006-12-22 to 2007-01-07.

## Resources

| Resource |
| --- |
| Jens |
| Borge |
| Rudi |
| Joachim |
| Chilo |
| Luciano |
| Danilo |
| JC |
| Uli |
| Antoine |
| Simonetti |
| Antje |
| Thomas |
| Daniel |
| Peter |
| Bergen |
| tc |
| Yannik |
| Werner |
| Lars |
| DBS |

## Schedule

| ID | WBS | Task | Duration | Start | Finish | Predecessors | Total slack | Free slack | Constraint | Resources | Work |
| --- | --- | --- | --- | --- | --- | --- | --- | --- | --- | --- | --- |
| 1 | 1 | completion of heat screen in SF | 15d | 2006-11-16 | 2006-11-30 |  | 41d |  | start no earlier than 2006-11-16 | Daniel; Thomas | 240h |
| 2 | 2 | C-side commissioning phase 2 | 21d | 2006-10-30 | 2006-11-19 |  | 0d |  | start no earlier than 2006-10-30 | Luciano; Joachim | 336h |
| 3 | 3 | remove VHV cable | 1d | 2006-11-20 | 2006-11-20 | 2 | 51d |  | start no earlier than 2006-11-07 | Joachim | 8h |
| 4 | 4 | disconnect services C-side, finalize covers | 2d | 2006-11-20 | 2006-11-21 | 2 | 9d | 5d | start no earlier than 2006-11-07 | Bergen | 16h |
| 5 | 5 | water manifold inner heat screen C-side | 2d | 2006-11-27 | 2006-11-28 | 4 | 4d | 0d | start no earlier than 2006-11-27 | Chilo; tc | 32h |
| 6 | 6 | leak test manifold C-side | 1d | 2006-11-29 | 2006-11-29 | 5 | 4d |  | start no earlier than 2006-11-08 | Chilo | 8h |
| 7 | 7 | water manifold inner heat screen A-side | 2d | 2006-12-04 | 2006-12-05 | 6, 32 | 0d |  | start no earlier than 2006-11-07 | Chilo; tc | 32h |
| 8 | 8 | leak test water manifold A-side | 1d | 2006-12-06 | 2006-12-06 | 7 | 0d |  | start no earlier than 2006-11-08 | Thomas | 8h |
| 9 | 9 | unhook gas | 1d | 2006-11-20 | 2006-11-20 | 2 | 0d |  | start no earlier than 2006-11-07 | Chilo | 8h |
| 10 | 10 | purge TPC with air | 3d | 2006-11-21 | 2006-11-23 | 9 | 0d |  | start no earlier than 2006-11-07 | Chilo | 24h |
| 11 | 11 | fix CO2 bottle to DF | 2d | 2006-11-21 | 2006-11-22 | 9 | 49d |  | start no earlier than 2006-11-07 | Chilo | 16h |
| 12 | 12 | MT ready | 1d | 2006-10-31 | 2006-10-31 |  | 68d | 0d | start no earlier than 2006-10-31 | JC | 8h |
| 13 | 13 | remove A00 FEE | 1d | 2006-11-01 | 2006-11-01 | 12 | 68d | 0d | start no earlier than 2006-11-01 | Antoine | 8h |
| 14 | 14 | remove FEE frame | 1d | 2006-11-02 | 2006-11-02 | 13 | 68d | 5d | start no earlier than 2006-11-02 | Uli; Rudi | 16h |
| 15 | 15 | remove A00 pt1000 | 1d | 2006-11-08 | 2006-11-08 | 14 | 63d |  | start no earlier than 2006-11-08 | Rudi | 8h |
| 16 | 16 | spare OROC testing | 15d | 2006-11-09 | 2006-11-23 |  | 0d |  | start no earlier than 2006-11-09 | Chilo; Rudi | 240h |
| 17 | 17 | prepare small pieces | 5d | 2006-11-01 | 2006-11-05 |  | 66d |  | start no earlier than 2006-11-01 | Danilo; Uli | 80h |
| 18 | 18 | clear out clean room | 2d | 2006-11-06 | 2006-11-07 |  | 61d | 0d | start no earlier than 2006-11-06 |  |  |
| 19 | 19 | cleaning | 3d | 2006-11-08 | 2006-11-10 | 18 | 61d |  |  |  |  |
| 20 | 20 | prepare platform | 4d | 2006-11-13 | 2006-11-16 |  | 55d |  | start no earlier than 2006-11-13 | JC | 32h |
| 21 | 21 | remove scaffold A-side | 1d | 2006-11-15 | 2006-11-15 |  | 56d |  | start no earlier than 2006-11-15 | JC | 8h |
| 22 | 22 | remove laser | 1d | 2006-11-15 | 2006-11-15 |  | 4d | 0d | start no earlier than 2006-11-15 | Borge; DBS | 16h |
| 23 | 23 | move platform into clean room | 1d | 2006-11-20 | 2006-11-20 |  | 48d | 0d | start no earlier than 2006-11-20 | JC; DBS | 16h |
| 24 | 24 | remove VHV | 1d | 2006-11-21 | 2006-11-21 | 23 | 50d |  |  | Joachim | 8h |
| 25 | 25 | complete platform | 3d | 2006-11-21 | 2006-11-23 | 23 | 48d |  |  | JC; tc | 48h |
| 26 | 26 | exchange OROC A00 | 1d | 2006-11-24 | 2006-11-24 | 10, 16 | 0d |  |  | Uli; JC | 16h |
| 27 | 27 | leak test | 2d | 2006-11-25 | 2006-11-26 | 26 | 0d |  | start no earlier than 2006-11-08 | Joachim | 16h |
| 28 | 28 | mount pt1000 | 1d | 2006-11-27 | 2006-11-27 | 27 | 0d |  | start no earlier than 2006-11-08 | Rudi; Uli | 16h |
| 29 | 29 | install ITS rail section | 1d | 2006-11-27 | 2006-11-27 | 27 | 44d |  | start no earlier than 2006-11-07 | Simonetti | 8h |
| 30 | 30 | mount frames services | 2d | 2006-11-28 | 2006-11-29 | 28 | 0d |  |  | Uli; Rudi | 32h |
| 31 | 31 | mount FEE | 1d | 2006-11-30 | 2006-11-30 | 30 | 0d |  |  | Antoine | 8h |
| 32 | 32 | test FEE, finalize covers A-side | 2d | 2006-12-01 | 2006-12-02 | 31 | 0d |  |  | Luciano | 16h |
| 33 | 33 | open roof, remove ACORDE | 2d | 2006-12-04 | 2006-12-05 | 32 | 37d |  | start no earlier than 2006-11-07 | Joachim; DBS | 32h |
| 34 | 34 | remove scaffolds C | 1d | 2006-12-04 | 2006-12-04 | 32, 6 | 38d |  | start no earlier than 2006-11-27 | JC; DBS | 16h |
| 35 | 35 | dismount and remove yellow platform | 2d | 2006-12-07 | 2006-12-08 | 8, 32 | 0d |  | start no earlier than 2006-11-07 | JC; tc; DBS | 48h |
| 36 | 36 | survey A/C | 1d | 2006-12-09 | 2006-12-09 | 35 | 0d |  | start no earlier than 2006-11-07 | Antje | 8h |
| 37 | 37 | package TPC | 1d | 2006-12-11 | 2006-12-11 | 36 | 0d |  | start no earlier than 2006-11-08 | Thomas; Joachim; DBS | 24h |
| 38 | 38 | contingency | 9d | 2006-12-12 | 2006-12-21 | 37 | 0d |  | start no earlier than 2006-11-13 |  |  |
| 39 | 39 | remove wall | 2d | 2007-01-08 | 2007-01-09 | 38 | 0d |  | start no earlier than 2007-01-08 | JC; DBS | 32h |
| 40 | 40 | prepare support beams for transport | 4d | 2006-11-27 | 2006-11-30 |  | 41d |  | start no earlier than 2006-11-27 | JC | 32h |
| 41 | 41 | black paint inner heat screen | 2d | 2006-11-20 | 2006-11-21 |  | 50d |  | start no earlier than 2006-11-20 | JC | 16h |
| 42 | 42 | tension bretelles | 1d | 2006-11-15 | 2006-11-15 |  | 56d |  | start no earlier than 2006-11-15 | Daniel | 8h |
| 43 | 43 | fix track-rods | 1d | 2006-11-15 | 2006-11-15 |  | 56d |  | start no earlier than 2006-11-15 | Peter | 8h |

| ID | WBS | Task | Duration | Start | Finish | Predecessors | Total slack | Free slack | Constraint | Resources | Work |
| --- | --- | --- | --- | --- | --- | --- | --- | --- | --- | --- | --- |
| 44 | 44 | **TPC transport** | 3d | 2007-01-10 | 2007-01-12 | 39 | 0d |  |  |  |  |
| 45 | 44.1 | TPC with crane to hydraulic station | 1d | 2007-01-10 | 2007-01-10 |  | 0d |  |  |  |  |
| 46 | 44.2 | TPC with trailer to SX2 | 1d | 2007-01-11 | 2007-01-11 | 45 | 0d |  | start no earlier than 2006-11-07 |  |  |
| 47 | 44.3 | TPC with cranes from SX2 to UX2 | 1d | 2007-01-12 | 2007-01-12 | 46 | 0d |  | start no earlier than 2006-11-07 |  |  |
| 48 | 45 | **TPC installation phase 3a** | 12d | 2007-01-13 | 2007-01-26 | 47 | 0d |  |  |  | 144h |
| 49 | 45.1 | align DF to SF | 3d | 2007-01-13 | 2007-01-16 |  | 0d |  | start no earlier than 2006-11-13 | Yannik | 24h |
| 50 | 45.2 | install transfer rails | 1d | 2007-01-17 | 2007-01-17 | 49 | 0d |  | start no earlier than 2006-11-13 | Yannik | 8h |
| 51 | 45.3 | move to IP under survey | 3d | 2007-01-18 | 2007-01-20 | 50 | 0d |  | start no earlier than 2006-11-13 | Antje; Yannik | 48h |
| 52 | 45.4 | align TPC at IP | 2d | 2007-01-22 | 2007-01-23 | 51 | 8d | 0d | start no earlier than 2006-11-13 | Yannik | 16h |
| 53 | 45.5 | align ITS rails at absorber | 1d | 2007-01-24 | 2007-01-24 | 52 | 8d |  | start no earlier than 2006-11-13 | Werner | 8h |
| 54 | 45.6 | install DF platform | 3d | 2007-01-22 | 2007-01-24 | 51 | 0d |  | start no earlier than 2006-11-13 | Lars | 24h |
| 55 | 45.7 | move TPC to parking | 2d | 2007-01-25 | 2007-01-26 | 54 | 0d |  | start no earlier than 2006-11-13 | Yannik | 16h |
| 56 | 46 | Install SF platform | 1d | 2007-01-27 | 2007-01-27 | 55 | 5d |  | start no earlier than 2006-11-13 |  |  |
| 57 | 47 | Install ITS table + rails | 6d | 2007-01-27 | 2007-02-02 | 55 | 0d |  | start no earlier than 2006-11-13 |  |  |
