# TPC Schedule in SXL2

Schedule from MS Project, 2006-10-30 to 2007-02-07.
ALICE

## Calendars

- Standard: Mon-Sat 08:00-12:00, 13:00-17:00; Sun off. Exceptions (off unless hours are given): 2006-11-04 to 2006-11-05 08:00-12:00, 13:00-17:00, 2006-11-11 to 2006-11-12 08:00-12:00, 13:00-17:00, 2006-11-18 to 2006-11-19 08:00-12:00, 13:00-17:00, 2006-11-25 to 2006-11-26, 2006-12-02, 2006-12-09, 2006-12-16, 2006-12-22 to 2007-01-07.

## Resources

| Resource |
| --- |
| Jens |
| Borge |
| Rudi |
| Joachim |
| Chilo |
| Luciano |
| Danilo |
| JC |
| Uli |
| Antoine |
| Simonetti |
| Antje |
| Thomas |
| Daniel |
| Peter |
| Bergen |
| tc |
| Yannik |
| Werner |
| Lars |
| DBS |
| Joachim,Chilo |
| Rainer, Rudi |
| Bjorn |
| Rainer |

## Schedule

| ID | WBS | Task | Duration | Start | Finish | Predecessors | Total slack | Free slack | Constraint | Resources | Work |
| --- | --- | --- | --- | --- | --- | --- | --- | --- | --- | --- | --- |
| 1 | 1 | completion of heat screen in SF | 15d | 2006-11-16 | 2006-12-04 |  | 40d |  | start no earlier than 2006-11-16 | Daniel; Thomas | 240h |
| 2 | 2 | C-side commissioning phase 2 | 21d | 2006-10-30 | 2006-11-19 |  | 0d |  | start no earlier than 2006-10-30 | Luciano; Joachim | 336h |
| 3 | 3 | remove VHV cable | 1d | 2006-11-20 | 2006-11-20 | 2 | 50d |  | start no earlier than 2006-11-07 | Joachim | 8h |
| 4 | 4 | disconnect services C-side, finalize covers | 5d | 2006-11-20 | 2006-11-24 | 2 | 0d |  | start no earlier than 2006-11-07 | Bergen | 40h |
| 5 | 5 | water manifold inner heat screen C-side | 2d | 2006-11-27 | 2006-11-28 | 4 | 0d |  | start no earlier than 2006-11-27 | Peter; tc | 32h |
| 6 | 6 | leak test manifold C-side | 1d | 2006-11-29 | 2006-11-29 | 5 | 42d | 2d | start no earlier than 2006-11-08 | Peter | 8h |
| 7 | 7 | more work on C-side: cabling, hoses ... | 10d | 2006-11-29 | 2006-12-12 | 5 | 0d |  | start no earlier than 2006-11-22 | Rainer, Rudi | 80h |
| 8 | 8 | water manifold inner heat screen A-side | 2d | 2006-12-01 | 2006-12-04 | 31, 6 | 0d |  | start no earlier than 2006-11-07 | Chilo; tc | 32h |
| 9 | 9 | leak test water manifold A-side | 1d | 2006-12-05 | 2006-12-05 | 8 | 0d |  | start no earlier than 2006-11-08 | Thomas | 8h |
| 10 | 10 | purge TPC with air | 3d | 2006-11-20 | 2006-11-22 |  | 0d |  | start no earlier than 2006-11-20 | Chilo | 24h |
| 11 | 11 | fix CO2 bottle to DF | 2d | 2006-11-07 | 2006-11-08 |  | 62d |  | start no earlier than 2006-11-07 | Chilo | 16h |
| 12 | 12 | MT ready | 1d | 2006-10-31 | 2006-10-31 |  | 67d | 0d | start no earlier than 2006-10-31 | JC | 8h |
| 13 | 13 | remove A00 FEE | 1d | 2006-11-01 | 2006-11-01 | 12 | 67d | 0d | start no earlier than 2006-11-01 | Antoine | 8h |
| 14 | 14 | remove FEE frame | 1d | 2006-11-02 | 2006-11-02 | 13 | 67d | 5d | start no earlier than 2006-11-02 | Uli; Rudi | 16h |
| 15 | 15 | remove A00 pt1000 | 1d | 2006-11-08 | 2006-11-08 | 14 | 62d |  | start no earlier than 2006-11-08 | Rudi | 8h |
| 16 | 16 | spare OROC testing | 13d | 2006-11-09 | 2006-11-21 |  | 1d |  | start no earlier than 2006-11-09 | Chilo; Rudi | 208h |
| 17 | 17 | prepare small pieces | 5d | 2006-11-01 | 2006-11-05 |  | 65d |  | start no earlier than 2006-11-01 | Danilo; Uli | 80h |
| 18 | 18 | clear out clean room | 2d | 2006-11-06 | 2006-11-07 |  | 60d | 0d | start no earlier than 2006-11-06 |  |  |
| 19 | 19 | cleaning | 3d | 2006-11-08 | 2006-11-10 | 18 | 60d |  |  |  |  |
| 20 | 20 | prepare platform | 4d | 2006-11-13 | 2006-11-16 |  | 54d |  | start no earlier than 2006-11-13 | JC | 32h |
| 21 | 21 | remove scaffold A-side | 1d | 2006-11-15 | 2006-11-15 |  | 55d |  | start no earlier than 2006-11-15 | JC | 8h |
| 22 | 22 | remove laser | 1d | 2006-11-15 | 2006-11-15 |  | 55d |  | start no earlier than 2006-11-15 | Borge; DBS | 16h |
| 23 | 23 | move platform into clean room | 1d | 2006-11-20 | 2006-11-20 |  | 48d | 0d | start no earlier than 2006-11-20 | JC; DBS | 16h |
| 24 | 24 | remove VHV | 1d | 2006-11-20 | 2006-11-20 |  | 50d |  | start no earlier than 2006-11-20 | Joachim | 8h |
| 25 | 25 | complete platform, prepare tools | 2d | 2006-11-21 | 2006-11-22 | 23 | 48d |  |  | JC; tc | 32h |
| 26 | 26 | exchange OROC A00, shim, seal | 1d | 2006-11-23 | 2006-11-23 | 10, 16 | 0d |  |  | Uli; JC; Danilo | 24h |
| 27 | 27 | leak test | 1d | 2006-11-24 | 2006-11-24 | 26 | 46d |  | start no earlier than 2006-11-08 | Joachim; Chilo | 16h |
| 28 | 28 | mount pt1000 | 1d | 2006-11-24 | 2006-11-24 | 26 | 0d |  | start no earlier than 2006-11-08 | Rudi; Uli | 16h |
| 29 | 29 | mount frames services | 2d | 2006-11-27 | 2006-11-28 | 28 | 0d |  |  | Uli; Rudi | 32h |
| 30 | 30 | mount FEE A00 | 1d | 2006-11-29 | 2006-11-29 | 29 | 0d |  |  | Antoine | 8h |
| 31 | 31 | test FEE A00 | 1d | 2006-11-30 | 2006-11-30 | 30 | 0d |  |  | Luciano | 8h |
| 32 | 32 | open roof, remove ACORDE | 2d | 2006-12-01 | 2006-12-04 | 31 | 42d |  | start no earlier than 2006-11-07 | Joachim; DBS | 32h |
| 33 | 33 | install IST rail sections | 1d | 2006-12-01 | 2006-12-01 | 31 | 41d |  | start no earlier than 2006-11-07 | Simonetti | 8h |
| 34 | 34 | more work on A-side | 3d | 2006-12-01 | 2006-12-05 | 31 | 39d |  | start no earlier than 2006-11-22 | Rainer, Rudi | 24h |
| 35 | 35 | dismount and remove yellow platform | 1d | 2006-12-06 | 2006-12-06 | 9, 31 | 0d |  | start no earlier than 2006-11-07 | JC; DBS | 16h |
| 36 | 36 | bring in scaffold A-side, move services | 1d | 2006-12-07 | 2006-12-07 | 35 | 0d |  | start no earlier than 2006-11-22 | Joachim; DBS | 16h |
| 37 | 37 | A05, A13 FEC, test | 2d | 2006-12-08 | 2006-12-11 | 36 | 35d |  | start no earlier than 2006-11-22 | Antoine; Luciano | 32h |
| 38 | 38 | install IST cameras | 1d | 2006-12-18 | 2006-12-18 | 36 | 30d |  | start no earlier than 2006-12-18 | Bjorn | 8h |
| 39 | 39 | A12 gating test | 1d | 2006-12-08 | 2006-12-08 | 36 | 36d |  | start no earlier than 2006-11-22 | Danilo | 8h |
| 40 | 40 | A-Side: finalize covers, more work | 3d | 2006-12-08 | 2006-12-12 | 36 | 0d |  | start no earlier than 2006-11-22 | Rainer | 24h |
| 41 | 41 | remove scaffolds A/C except one each side | 1d | 2006-12-13 | 2006-12-13 | 40, 7 | 0d |  | start no earlier than 2006-11-22 | Joachim; DBS | 16h |
| 42 | 42 | survey A/C | 1d | 2006-12-14 | 2006-12-14 | 41 | 0d |  | start no earlier than 2006-11-07 | Antje | 8h |
| 43 | 43 | prepare packaging of TPC | 14d | 2006-11-27 | 2006-12-14 |  | 0d |  | start no earlier than 2006-11-27 |  |  |
| 44 | 44 | package TPC | 2d | 2006-12-15 | 2006-12-18 | 42, 43 | 0d |  | start no earlier than 2006-11-08 | Thomas; Joachim; DBS | 48h |
| 45 | 45 | contingency | 3d | 2006-12-19 | 2006-12-21 | 44 | 0d |  | start no earlier than 2006-11-13 |  |  |
| 46 | 46 | prepare support beams for transport | 4d | 2006-11-27 | 2006-11-30 |  | 42d |  | start no earlier than 2006-11-27 | JC | 32h |
| 47 | 47 | black paint inner heat screen | 2d | 2006-11-20 | 2006-11-21 |  | 49d |  | start no earlier than 2006-11-20 | JC | 16h |
| 48 | 48 | tension bretelles | 1d | 2006-11-15 | 2006-11-15 |  | 55d |  | start no earlier than 2006-11-15 | Daniel | 8h |
| 49 | 49 | fix track-rods | 1d | 2006-11-15 | 2006-11-15 |  | 55d |  | start no earlier than 2006-11-15 | Peter | 8h |
| 50 | 50 | remove wall | 2d | 2007-01-08 | 2007-01-09 | 45 | 0d |  | start no earlier than 2007-01-08 | JC; DBS | 32h |

| ID | WBS | Task | Type | Duration | Start | Finish | Predecessors | Total slack | Free slack | Constraint | Resources | Work |
| --- | --- | --- | --- | --- | --- | --- | --- | --- | --- | --- | --- | --- |
| 51 | 51 | **TPC transport** |  | 3d | 2007-01-10 | 2007-01-12 | 50 | 0d |  |  |  |  |
| 52 | 51.1 | TPC with crane to hydraulic station |  | 1d | 2007-01-10 | 2007-01-10 |  | 0d |  |  |  |  |
| 53 | 51.2 | TPC with trailer to SX2 |  | 1d | 2007-01-11 | 2007-01-11 | 52 | 0d |  | start no earlier than 2006-11-07 |  |  |
| 54 | 51.3 | TPC with cranes from SX2 to UX2 |  | 1d | 2007-01-12 | 2007-01-12 | 53 | 0d |  | start no earlier than 2006-11-07 |  |  |
| 55 | 52 | **TPC installation phase 3a** |  | 13d | 2007-01-13 | 2007-01-27 | 54 | 0d |  |  |  | 176h |
| 56 | 52.1 | position on support blocks |  | 1d | 2007-01-13 | 2007-01-13 |  | 0d |  | start no earlier than 2006-11-23 | Yannik | 8h |
| 57 | 52.2 | align DF to SF |  | 3d | 2007-01-15 | 2007-01-17 | 56 | 0d |  | start no earlier than 2006-11-13 | Yannik; Antje | 48h |
| 58 | 52.3 | install transfer rails |  | 1d | 2007-01-18 | 2007-01-18 | 57 | 0d |  | start no earlier than 2006-11-13 | Yannik | 8h |
| 59 | 52.4 | move to IP under survey |  | 3d | 2007-01-19 | 2007-01-22 | 58 | 0d |  | start no earlier than 2006-11-13 | Antje; Yannik | 48h |
| 60 | 52.5 | align TPC at IP |  | 2d | 2007-01-23 | 2007-01-24 | 59 | 11d | 0d | start no earlier than 2006-11-13 | Yannik | 16h |
| 61 | 52.6 | align ITS rails at absorber |  | 1d | 2007-01-25 | 2007-01-25 | 60 | 11d |  | start no earlier than 2006-11-13 | Werner | 8h |
| 62 | 52.7 | install DF platform |  | 3d | 2007-01-23 | 2007-01-25 | 59 | 0d |  | start no earlier than 2006-11-13 | Lars | 24h |
| 63 | 52.8 | move TPC to parking |  | 2d | 2007-01-26 | 2007-01-27 | 62 | 0d |  | start no earlier than 2006-11-13 | Yannik | 16h |
| 64 | 53 | Install SF platform |  | 1d | 2007-01-29 | 2007-01-29 | 63 | 8d |  | start no earlier than 2006-11-13 |  |  |
| 65 | 54 | Install ITS table + rails |  | 6d | 2007-01-29 | 2007-02-03 | 63 | 0d |  | start no earlier than 2006-11-13 |  |  |
| 66 | 55 | contingency |  | 3d | 2007-02-05 | 2007-02-07 | 65 | 0d |  | start no earlier than 2006-11-22 |  |  |
| 67 | 56 | ready to install Be beam pipe 7.2. | milestone | 0d | 2007-02-07 | 2007-02-07 | 66 | 0d |  | start no earlier than 2006-11-22 |  |  |
