# TPC Schedule in SXL2

Schedule from MS Project, 2006-10-30 to 2007-01-31.
ALICE

## Calendars

- Standard: Mon-Sat 08:00-12:00, 13:00-17:00; Sun off. Exceptions (off unless hours are given): 2006-11-04 to 2006-11-05 08:00-12:00, 13:00-17:00, 2006-11-11 to 2006-11-12 08:00-12:00, 13:00-17:00, 2006-11-18 to 2006-11-19 08:00-12:00, 13:00-17:00, 2006-11-25 to 2006-11-26, 2006-12-02, 2006-12-09, 2006-12-16, 2006-12-22 to 2007-01-07.

## Resources

| Resource |
| --- |
| Jens |
| Borge |
| Rudi |
| Joachim |
| Chilo |
| Luciano |
| Danilo |
| JC |
| Uli |
| Antoine |
| Simonetti |
| Antje |
| Thomas |
| Daniel |
| Peter |
| Bergen |
| tc |
| Yannik |
| Werner |
| Lars |
| DBS |
| Joachim,Chilo |
| Rainer, Rudi |
| Bjorn |
| Rainer |

## Schedule

| ID | WBS | Task | Duration | Start | Finish | Predecessors | Total slack | Free slack | Constraint | Resources | Work |
| --- | --- | --- | --- | --- | --- | --- | --- | --- | --- | --- | --- |
| 1 | 1 | completion of heat screen in SF | 15d | 2006-11-16 | 2006-12-04 |  | 40d |  | start no earlier than 2006-11-16 | Daniel; Thomas | 240h |
| 2 | 2 | C-side commissioning phase 2 | 21d | 2006-10-30 | 2006-11-19 |  | 3d | 0d | start no earlier than 2006-10-30 | Luciano; Joachim | 336h |
| 3 | 3 | remove VHV cable | 1d | 2006-11-20 | 2006-11-20 | 2 | 50d |  | start no earlier than 2006-11-07 | Joachim | 8h |
| 4 | 4 | disconnect services C-side, finalize covers | 5d | 2006-11-20 | 2006-11-24 | 2 | 3d |  | start no earlier than 2006-11-07 | Bergen | 40h |
| 5 | 5 | water manifold inner heat screen C-side | 2d | 2006-11-30 | 2006-12-01 | 4 | 0d |  | start no earlier than 2006-11-30 | Peter; tc | 32h |
| 6 | 6 | leak test manifold C-side | 1d | 2006-12-04 | 2006-12-04 | 5 | 2d | 0d | start no earlier than 2006-11-08 | Peter | 8h |
| 7 | 7 | more work on C-side: cabling, hoses ... | 6d | 2006-12-04 | 2006-12-11 | 5 | 0d |  | start no earlier than 2006-11-22 | Rainer, Rudi | 48h |
| 8 | 8 | water manifold inner heat screen A-side | 2d | 2006-12-05 | 2006-12-06 | 33, 6 | 2d | 0d | start no earlier than 2006-11-07 | Chilo; tc | 32h |
| 9 | 9 | leak test water manifold A-side | 1d | 2006-12-07 | 2006-12-07 | 8 | 2d |  | start no earlier than 2006-11-08 | Thomas | 8h |
| 10 | 10 | purge TPC with air | 3d | 2006-11-20 | 2006-11-22 |  | 1d | 0d | start no earlier than 2006-11-20 | Chilo | 24h |
| 11 | 11 | fix CO2 bottle to DF | 2d | 2006-11-07 | 2006-11-08 |  | 62d |  | start no earlier than 2006-11-07 | Chilo | 16h |
| 12 | 12 | MT ready | 1d | 2006-10-31 | 2006-10-31 |  | 67d | 0d | start no earlier than 2006-10-31 | JC | 8h |
| 13 | 13 | remove A00 FEE | 1d | 2006-11-01 | 2006-11-01 | 12 | 67d | 0d | start no earlier than 2006-11-01 | Antoine | 8h |
| 14 | 14 | remove FEE frame | 1d | 2006-11-02 | 2006-11-02 | 13 | 67d | 5d | start no earlier than 2006-11-02 | Uli; Rudi | 16h |
| 15 | 15 | remove A00 pt1000 | 1d | 2006-11-08 | 2006-11-08 | 14 | 62d |  | start no earlier than 2006-11-08 | Rudi | 8h |
| 16 | 16 | spare OROC testing | 13d | 2006-11-09 | 2006-11-21 |  | 1d |  | start no earlier than 2006-11-09 | Chilo; Rudi | 208h |
| 17 | 17 | prepare small pieces | 5d | 2006-11-01 | 2006-11-05 |  | 65d |  | start no earlier than 2006-11-01 | Danilo; Uli | 80h |
| 18 | 18 | clear out clean room | 2d | 2006-11-06 | 2006-11-07 |  | 60d | 0d | start no earlier than 2006-11-06 |  |  |
| 19 | 19 | cleaning | 3d | 2006-11-08 | 2006-11-10 | 18 | 60d |  |  |  |  |
| 20 | 20 | prepare platform | 4d | 2006-11-13 | 2006-11-16 |  | 54d |  | start no earlier than 2006-11-13 | JC | 32h |
| 21 | 21 | remove scaffold A-side | 1d | 2006-11-15 | 2006-11-15 |  | 55d |  | start no earlier than 2006-11-15 | JC | 8h |
| 22 | 22 | remove laser | 1d | 2006-11-15 | 2006-11-15 |  | 55d |  | start no earlier than 2006-11-15 | Borge; DBS | 16h |
| 23 | 23 | move platform into clean room | 1d | 2006-11-20 | 2006-11-20 |  | 48d | 0d | start no earlier than 2006-11-20 | JC; DBS | 16h |
| 24 | 24 | remove VHV | 1d | 2006-11-20 | 2006-11-20 |  | 50d |  | start no earlier than 2006-11-20 | Joachim | 8h |
| 25 | 25 | complete platform, prepare tools | 2d | 2006-11-21 | 2006-11-22 | 23 | 48d |  |  | JC; tc | 32h |
| 26 | 26 | exchange OROC A00, shim, seal | 1d | 2006-11-23 | 2006-11-23 | 10, 16 | 1d | 0d |  | Uli; JC; Danilo | 24h |
| 27 | 27 | leak test | 1d | 2006-11-24 | 2006-11-24 | 26 | 46d |  | start no earlier than 2006-11-08 | Joachim; Chilo | 16h |
| 28 | 28 | mount pt1000 | 1d | 2006-11-24 | 2006-11-24 | 26 | 1d | 0d | start no earlier than 2006-11-08 | Rudi; Uli | 16h |
| 29 | 29 | mount frames services | 1d | 2006-11-27 | 2006-11-27 | 28 | 1d | 0d |  | Uli; Danilo | 16h |
| 30 | 30 | mount FEE A00 | 2d | 2006-11-28 | 2006-11-29 | 29 | 1d | 0d |  | Antoine | 16h |
| 31 | 31 | modify platform, remove ACORDE | 1d | 2006-11-30 | 2006-11-30 | 30 | 1d | 0d | start no earlier than 2006-11-07 | Joachim; DBS | 16h |
| 32 | 32 | bring in scaffold A-side, move services | 1d | 2006-12-01 | 2006-12-01 | 31 | 1d | 0d | start no earlier than 2006-11-22 | Joachim; DBS | 16h |
| 33 | 33 | test FEE A00, new Wiener 2 sectors | 1d | 2006-12-01 | 2006-12-01 | 31 | 3d | 0d |  | Luciano | 8h |
| 34 | 34 | dismount and remove yellow platform | 1d | 2006-12-04 | 2006-12-04 | 33 | 39d | 0d | start no earlier than 2006-11-07 | JC; DBS | 16h |
| 35 | 35 | install ITS rail sections | 1d | 2006-12-05 | 2006-12-05 | 34 | 33d |  | start no earlier than 2006-11-07 | Simonetti | 8h |
| 36 | 36 | A05, A13 FEC, test | 2d | 2006-12-04 | 2006-12-05 | 32 | 39d |  | start no earlier than 2006-11-22 | Antoine; Luciano | 32h |
| 37 | 37 | install ITS cameras | 1d | 2006-12-18 | 2006-12-18 | 32 | 24d |  | start no earlier than 2006-12-18 | Bjorn | 8h |
| 38 | 38 | A12 gating test | 1d | 2006-12-04 | 2006-12-04 | 32 | 40d |  | start no earlier than 2006-11-22 | Danilo | 8h |
| 39 | 39 | noise studies | 3d | 2006-12-04 | 2006-12-06 | 32 | 38d |  | start no earlier than 2006-11-28 | Luciano | 24h |
| 40 | 40 | A-Side: finalize covers, more work | 5d | 2006-12-04 | 2006-12-08 | 32 | 1d |  | start no earlier than 2006-11-22 | Rainer | 40h |
| 41 | 41 | remove scaffolds A/C except one each side | 1d | 2006-12-12 | 2006-12-12 | 40, 7, 9 | 0d |  | start no earlier than 2006-11-22 | Joachim; DBS | 16h |
| 42 | 42 | survey A/C | 1d | 2006-12-13 | 2006-12-13 | 41 | 0d |  | start no earlier than 2006-11-07 | Antje | 8h |
| 43 | 43 | prepare packaging of TPC | 12d | 2006-11-27 | 2006-12-12 |  | 1d |  | start no earlier than 2006-11-27 |  |  |
| 44 | 44 | package TPC | 2d | 2006-12-14 | 2006-12-15 | 42, 43 | 25d |  | start no earlier than 2006-11-08 | Thomas; Joachim; DBS | 48h |
| 45 | 45 | prepare support beams for transport | 4d | 2006-11-27 | 2006-11-30 |  | 36d |  | start no earlier than 2006-11-27 | JC | 32h |
| 46 | 46 | black paint inner heat screen | 2d | 2006-11-29 | 2006-11-30 |  | 36d |  | start no earlier than 2006-11-29 | JC | 16h |
| 47 | 47 | tension bretelles | 1d | 2006-11-15 | 2006-11-15 |  | 49d |  | start no earlier than 2006-11-15 | Daniel | 8h |
| 48 | 48 | fix track-rods | 1d | 2006-11-15 | 2006-11-15 |  | 49d |  | start no earlier than 2006-11-15 | Peter | 8h |
| 49 | 49 | remove wall | 2d | 2006-12-14 | 2006-12-15 | 42 | 0d |  | start no earlier than 2006-12-14 | JC; DBS | 32h |

| ID | WBS | Task | Type | Duration | Start | Finish | Predecessors | Total slack | Free slack | Constraint | Resources | Work |
| --- | --- | --- | --- | --- | --- | --- | --- | --- | --- | --- | --- | --- |
| 50 | 50 | **TPC transport** |  | 3d | 2006-12-18 | 2006-12-20 | 49 | 0d |  |  |  |  |
| 51 | 50.1 | TPC with crane to hydraulic station |  | 1d | 2006-12-18 | 2006-12-18 |  | 0d |  |  |  |  |
| 52 | 50.2 | TPC with trailer to SX2 |  | 1d | 2006-12-19 | 2006-12-19 | 51 | 0d |  | start no earlier than 2006-11-07 |  |  |
| 53 | 50.3 | TPC with cranes from SX2 to UX2 |  | 1d | 2006-12-20 | 2006-12-20 | 52 | 0d |  | start no earlier than 2006-11-07 |  |  |
| 54 | 51 | **TPC installation phase 3a** |  | 13d | 2006-12-21 | 2007-01-20 | 53 | 0d |  |  |  | 176h |
| 55 | 51.1 | position on support blocks |  | 1d | 2006-12-21 | 2006-12-21 |  | 0d |  | start no earlier than 2006-11-23 | Yannik | 8h |
| 56 | 51.2 | align DF to SF |  | 3d | 2007-01-08 | 2007-01-10 | 55 | 0d |  | start no earlier than 2006-11-13 | Yannik; Antje | 48h |
| 57 | 51.3 | install transfer rails |  | 1d | 2007-01-11 | 2007-01-11 | 56 | 0d |  | start no earlier than 2006-11-13 | Yannik | 8h |
| 58 | 51.4 | move to IP under survey |  | 3d | 2007-01-12 | 2007-01-15 | 57 | 0d |  | start no earlier than 2006-11-13 | Antje; Yannik | 48h |
| 59 | 51.5 | align TPC at IP |  | 2d | 2007-01-16 | 2007-01-17 | 58 | 11d | 0d | start no earlier than 2006-11-13 | Yannik | 16h |
| 60 | 51.6 | align ITS rails at absorber |  | 1d | 2007-01-18 | 2007-01-18 | 59 | 11d |  | start no earlier than 2006-11-13 | Werner | 8h |
| 61 | 51.7 | install DF platform |  | 3d | 2007-01-16 | 2007-01-18 | 58 | 0d |  | start no earlier than 2006-11-13 | Lars | 24h |
| 62 | 51.8 | move TPC to parking |  | 2d | 2007-01-19 | 2007-01-20 | 61 | 0d |  | start no earlier than 2006-11-13 | Yannik | 16h |
| 63 | 52 | Install SF platform |  | 1d | 2007-01-22 | 2007-01-22 | 62 | 8d |  | start no earlier than 2006-11-13 |  |  |
| 64 | 53 | Install ITS table + rails |  | 6d | 2007-01-22 | 2007-01-27 | 62 | 0d |  | start no earlier than 2006-11-13 |  |  |
| 65 | 54 | contingency |  | 3d | 2007-01-29 | 2007-01-31 | 64 | 0d |  | start no earlier than 2006-11-22 |  |  |
| 66 | 55 | ready to install Be beam pipe 7.2. | milestone | 0d | 2007-01-31 | 2007-01-31 | 65 | 0d |  | start no earlier than 2006-11-22 |  |  |
