# TPC Schedule in SXL2

Schedule from MS Project, 2006-10-30 to 2007-02-05.
ALICE

## Calendars

- Standard: Mon-Sat 08:00-12:00, 13:00-17:00; Sun off. Exceptions (off unless hours are given): 2006-11-04 to 2006-11-05 08:00-12:00, 13:00-17:00, 2006-11-11 to 2006-11-12 08:00-12:00, 13:00-17:00, 2006-11-18 to 2006-11-19 08:00-12:00, 13:00-17:00, 2006-11-25 to 2006-11-26, 2006-12-02, 2006-12-09, 2006-12-16, 2006-12-22 to 2007-01-03, 2007-01-06 to 2007-01-07.

## Resources

| Resource |
| --- |
| Jens |
| Borge |
| Rudi |
| Joachim |
| Chilo |
| Luciano |
| Danilo |
| JC |
| Uli |
| Antoine |
| Simonetti |
| Antje |
| Thomas |
| Daniel |
| Peter |
| Bergen |
| tc |
| Yannik |
| Werner |
| Lars |
| DBS |
| Joachim,Chilo |
| Rainer, Rudi |
| Bjorn |
| Rainer |
| Rainer,Roberto |

## Schedule

| ID | WBS | Task | Duration | Start | Finish | Predecessors | Total slack | Free slack | Constraint | Resources | Work |
| --- | --- | --- | --- | --- | --- | --- | --- | --- | --- | --- | --- |
| 1 | 1 | completion of heat screen in SF | 15d | 2006-11-16 | 2006-12-04 |  | 40d |  | start no earlier than 2006-11-16 | Daniel; Thomas | 240h |
| 2 | 2 | C-side commissioning phase 2 | 21d | 2006-10-30 | 2006-11-19 |  | 9d | 0d | start no earlier than 2006-10-30 | Luciano; Joachim | 336h |
| 3 | 3 | remove VHV cable | 1d | 2006-11-20 | 2006-11-20 | 2 | 50d |  | start no earlier than 2006-11-07 | Joachim | 8h |
| 4 | 4 | disconnect services C-side, finalize covers | 5d | 2006-11-20 | 2006-11-24 | 2 | 9d | 3d | start no earlier than 2006-11-07 | Bergen | 40h |
| 5 | 5 | water manifold inner heat screen C-side | 2d | 2006-11-30 | 2006-12-01 | 4 | 31d | 0d | start no earlier than 2006-11-30 | Peter; tc | 32h |
| 6 | 6 | leak test manifold C-side | 1d | 2006-12-04 | 2006-12-04 | 5 | 8d | 0d | start no earlier than 2006-11-08 | Peter | 8h |
| 7 | 7 | more work on C-side: cabling, hoses ... | 10d | 2006-12-04 | 2006-12-15 | 5 | 31d |  | start no earlier than 2006-11-22 | Rainer, Rudi | 80h |
| 8 | 8 | water manifold inner heat screen A-side | 2d | 2006-12-05 | 2006-12-06 | 33, 6 | 8d | 0d | start no earlier than 2006-11-07 | Chilo; tc | 32h |
| 9 | 9 | leak test water manifold A-side | 1d | 2006-12-07 | 2006-12-07 | 8 | 8d | 7d | start no earlier than 2006-11-08 | Thomas | 8h |
| 10 | 10 | purge TPC with air | 3d | 2006-11-20 | 2006-11-22 |  | 0d |  | start no earlier than 2006-11-20 | Chilo | 24h |
| 11 | 11 | fix CO2 bottle to DF | 2d | 2006-11-07 | 2006-11-08 |  | 62d |  | start no earlier than 2006-11-07 | Chilo | 16h |
| 12 | 12 | MT ready | 1d | 2006-10-31 | 2006-10-31 |  | 67d | 0d | start no earlier than 2006-10-31 | JC | 8h |
| 13 | 13 | remove A00 FEE | 1d | 2006-11-01 | 2006-11-01 | 12 | 67d | 0d | start no earlier than 2006-11-01 | Antoine | 8h |
| 14 | 14 | remove FEE frame | 1d | 2006-11-02 | 2006-11-02 | 13 | 67d | 5d | start no earlier than 2006-11-02 | Uli; Rudi | 16h |
| 15 | 15 | remove A00 pt1000 | 1d | 2006-11-08 | 2006-11-08 | 14 | 62d |  | start no earlier than 2006-11-08 | Rudi | 8h |
| 16 | 16 | spare OROC testing | 13d | 2006-11-09 | 2006-11-21 |  | 3d | 1d | start no earlier than 2006-11-09 | Chilo; Rudi | 208h |
| 17 | 17 | prepare small pieces | 5d | 2006-11-01 | 2006-11-05 |  | 65d |  | start no earlier than 2006-11-01 | Danilo; Uli | 80h |
| 18 | 18 | clear out clean room | 2d | 2006-11-06 | 2006-11-07 |  | 60d | 0d | start no earlier than 2006-11-06 |  |  |
| 19 | 19 | cleaning | 3d | 2006-11-08 | 2006-11-10 | 18 | 60d |  |  |  |  |
| 20 | 20 | prepare platform | 4d | 2006-11-13 | 2006-11-16 |  | 54d |  | start no earlier than 2006-11-13 | JC | 32h |
| 21 | 21 | remove scaffold A-side | 1d | 2006-11-15 | 2006-11-15 |  | 55d |  | start no earlier than 2006-11-15 | JC | 8h |
| 22 | 22 | remove laser | 1d | 2006-11-15 | 2006-11-15 |  | 55d |  | start no earlier than 2006-11-15 | Borge; DBS | 16h |
| 23 | 23 | move platform into clean room | 1d | 2006-11-20 | 2006-11-20 |  | 48d | 0d | start no earlier than 2006-11-20 | JC; DBS | 16h |
| 24 | 24 | remove VHV | 1d | 2006-11-20 | 2006-11-20 |  | 50d |  | start no earlier than 2006-11-20 | Joachim | 8h |
| 25 | 25 | complete platform, prepare tools | 2d | 2006-11-21 | 2006-11-22 | 23 | 48d |  |  | JC; tc | 32h |
| 26 | 26 | exchange OROC A00, shim, seal | 1d | 2006-11-23 | 2006-11-23 | 10, 16 | 0d |  |  | Uli; JC; Danilo | 24h |
| 27 | 27 | leak test | 1d | 2006-11-24 | 2006-11-24 | 26 | 46d |  | start no earlier than 2006-11-08 | Joachim; Chilo | 16h |
| 28 | 28 | mount pt1000 | 1d | 2006-11-24 | 2006-11-24 | 26 | 0d |  | start no earlier than 2006-11-08 | Rudi; Uli | 16h |
| 29 | 29 | mount frames services | 1d | 2006-11-27 | 2006-11-27 | 28 | 0d |  |  | Uli; Danilo | 16h |
| 30 | 30 | mount FEE A00 | 2d | 2006-11-28 | 2006-11-29 | 29 | 0d |  |  | Antoine | 16h |
| 31 | 31 | modify platform, remove ACORDE | 1d | 2006-11-30 | 2006-11-30 | 30 | 0d |  | start no earlier than 2006-11-07 | Joachim; DBS | 16h |
| 32 | 32 | move services | 1d | 2006-12-01 | 2006-12-01 | 31 | 0d |  | start no earlier than 2006-12-01 | Rainer,Roberto | 8h |
| 33 | 33 | test FEE A00, new Wiener 2 sectors | 1d | 2006-12-04 | 2006-12-04 | 32 | 0d |  |  | Luciano | 8h |
| 34 | 34 | install ITS rail sections | 1d | 2006-12-05 | 2006-12-05 |  | 39d |  | start no earlier than 2006-12-05 | Simonetti | 8h |
| 35 | 35 | A05, A13 FEC, test | 1d | 2006-12-05 | 2006-12-05 | 33 | 0d |  | start no earlier than 2006-11-22 | Antoine; Luciano | 16h |
| 36 | 36 | A12 gating test | 1d | 2006-12-06 | 2006-12-06 | 35 | 38d |  | start no earlier than 2006-11-22 | Danilo | 8h |
| 37 | 37 | noise studies, ground modification | 8d | 2006-12-06 | 2006-12-15 | 35 | 0d |  | start no earlier than 2006-11-28 | Luciano | 64h |
| 38 | 38 | A-Side: finalize covers, more work | 10d | 2006-12-01 | 2006-12-14 | 31 | 1d |  | start no earlier than 2006-11-22 | Rainer | 80h |
| 39 | 39 | dismount and remove yellow platform | 1d | 2006-12-18 | 2006-12-18 | 37, 38 | 30d |  | start no earlier than 2006-11-07 | JC; DBS | 16h |
| 40 | 40 | remove scaffolds A/C except one each side | 1d | 2006-12-18 | 2006-12-18 | 37, 38 | 0d |  | start no earlier than 2006-11-22 | Joachim; DBS | 16h |
| 41 | 41 | survey A/C | 1d | 2006-12-19 | 2006-12-19 | 40 | 0d |  | start no earlier than 2006-11-07 | Antje | 8h |
| 42 | 42 | packaging of TPC, prepare, start I/O | 5d | 2006-12-11 | 2006-12-15 |  | 32d |  | start no earlier than 2006-12-11 | JC | 40h |
| 43 | 43 | install ITS cameras | 1d | 2006-12-18 | 2006-12-18 |  | 30d |  | start no earlier than 2006-12-18 | Bjorn | 8h |
| 44 | 44 | package TPC | 2d | 2006-12-20 | 2006-12-21 | 41 | 0d |  | start no earlier than 2006-11-08 | Thomas; Joachim; DBS | 48h |
| 45 | 45 | prepare support beams for transport | 1d | 2006-11-30 | 2006-11-30 |  | 42d |  | start no earlier than 2006-11-30 | JC | 8h |
| 46 | 46 | black paint inner heat screen | 3d | 2006-11-29 | 2006-12-01 |  | 41d |  | start no earlier than 2006-11-29 | JC | 24h |
| 47 | 47 | tension bretelles | 1d | 2006-11-15 | 2006-11-15 |  | 55d |  | start no earlier than 2006-11-15 | Daniel | 8h |
| 48 | 48 | fix track-rods | 1d | 2006-12-07 | 2006-12-07 |  | 38d |  | start no earlier than 2006-12-07 | Peter | 8h |
| 49 | 49 | remove wall | 2d | 2007-01-04 | 2007-01-05 | 41, 44 | 0d |  | start no earlier than 2007-01-04 | JC; DBS | 32h |

| ID | WBS | Task | Type | Duration | Start | Finish | Predecessors | Total slack | Free slack | Constraint | Resources | Work |
| --- | --- | --- | --- | --- | --- | --- | --- | --- | --- | --- | --- | --- |
| 50 | 50 | **TPC transport** |  | 3d | 2007-01-08 | 2007-01-10 | 49 | 0d |  |  |  |  |
| 51 | 50.1 | TPC with crane to hydraulic station |  | 1d | 2007-01-08 | 2007-01-08 |  | 0d |  |  |  |  |
| 52 | 50.2 | TPC with trailer to SX2 and UX2 shaft pos |  | 1d | 2007-01-09 | 2007-01-09 | 51 | 0d |  | start no earlier than 2006-11-07 |  |  |
| 53 | 50.3 | DF to final position |  | 1d | 2007-01-10 | 2007-01-10 | 52 | 0d |  | start no earlier than 2006-12-06 |  |  |
| 54 | 51 | heat screen: special panels for IST access |  | 2d | 2007-01-08 | 2007-01-09 |  | 23d |  | start no earlier than 2007-01-08 | Thomas | 16h |
| 55 | 52 | **TPC installation phase 3a** |  | 13d | 2007-01-11 | 2007-01-25 | 53 | 0d |  |  |  | 176h |
| 56 | 52.1 | position on support blocks |  | 1d | 2007-01-11 | 2007-01-11 |  | 0d |  | start no earlier than 2006-11-23 | Yannik | 8h |
| 57 | 52.2 | align DF to SF |  | 3d | 2007-01-12 | 2007-01-15 | 56 | 0d |  | start no earlier than 2006-11-13 | Yannik; Antje | 48h |
| 58 | 52.3 | install transfer rails |  | 1d | 2007-01-16 | 2007-01-16 | 57 | 0d |  | start no earlier than 2006-11-13 | Yannik | 8h |
| 59 | 52.4 | move to IP under survey |  | 3d | 2007-01-17 | 2007-01-19 | 58 | 0d |  | start no earlier than 2006-11-13 | Antje; Yannik | 48h |
| 60 | 52.5 | align TPC at IP |  | 2d | 2007-01-20 | 2007-01-22 | 59 | 11d | 0d | start no earlier than 2006-11-13 | Yannik | 16h |
| 61 | 52.6 | align ITS rails at absorber |  | 1d | 2007-01-23 | 2007-01-23 | 60 | 11d |  | start no earlier than 2006-11-13 | Werner | 8h |
| 62 | 52.7 | install DF platform |  | 3d | 2007-01-20 | 2007-01-23 | 59 | 0d |  | start no earlier than 2006-11-13 | Lars | 24h |
| 63 | 52.8 | move TPC to parking |  | 2d | 2007-01-24 | 2007-01-25 | 62 | 0d |  | start no earlier than 2006-11-13 | Yannik | 16h |
| 64 | 53 | Install SF platform |  | 1d | 2007-01-26 | 2007-01-26 | 63 | 8d |  | start no earlier than 2006-11-13 |  |  |
| 65 | 54 | Install ITS table + rails |  | 6d | 2007-01-26 | 2007-02-01 | 63 | 0d |  | start no earlier than 2006-11-13 |  |  |
| 66 | 55 | contingency |  | 3d | 2007-02-02 | 2007-02-05 | 65 | 0d |  | start no earlier than 2006-11-22 |  |  |
| 67 | 56 | ready to install Be beam pipe 7.2. | milestone | 0d | 2007-02-05 | 2007-02-05 | 66 | 0d |  | start no earlier than 2006-11-22 |  |  |
